# CRONOPROGRAMMA LAVORI MERATE

Schedule from MS Project, 2014-03-03 to 2014-12-04, status date 2013-07-02.
ENTERPRISE

## Calendars

- Standard: Mon-Fri 08:00-12:00, 13:30-18:00; Sat-Sun off. Exceptions (off unless hours are given): 2014-08-01 to 2014-08-31.

## Resources

| Resource | Group |
| --- | --- |
| OPERE EDILI | edili |
| OPERE ELETTRICHE 1 | elettricisti |
| OPERE ELETTRICHE 2 |  |

## Schedule

| ID | WBS | Task | Duration | Start | Finish | Predecessors | Total slack | Free slack | Constraint | Deadline | Resources | Work |
| --- | --- | --- | --- | --- | --- | --- | --- | --- | --- | --- | --- | --- |
| 1 | 1 | **OPERE EDILI INTERVENTI OBBLIGATORI** | 79d | 2014-03-10 | 2014-06-20 |  | -84.25d | 0d |  |  |  | 632h |
| 2 | 1.1 | **OPERE EDILI VIA TRENTO** | 8d | 2014-03-10 | 2014-03-19 |  | -84.25d | 0d |  |  |  | 64h |
| 3 | 1.1.1 | OPERE DI CANALIZZAZIONE | 5d | 2014-03-10 | 2014-03-14 |  | -84.25d | 0d | start no earlier than 2014-03-10 |  | OPERE EDILI | 40h |
| 4 | 1.1.2 | GETTI DI FONDAZIONE | 1d | 2014-03-14 | 2014-03-17 | 3 | -84.25d | 0d |  |  | OPERE EDILI | 8h |
| 5 | 1.1.3 | OPERE DI RIPRISTINO STRADA | 2d | 2014-03-17 | 2014-03-19 | 4 | -84.25d | 0d |  | 2013-12-03 | OPERE EDILI | 16h |
| 6 | 1.2 | **OPERE EDILI VIA GIOVANNI XXVIII** | 4d | 2014-03-19 | 2014-03-25 |  | -84.25d | 0d |  |  |  | 32h |
| 7 | 1.2.1 | OPERE DI CANALIZZAZIONE | 2d | 2014-03-19 | 2014-03-21 | 5 | -84.25d | 0d |  |  | OPERE EDILI | 16h |
| 8 | 1.2.2 | GETTI DI FONDAZIONE | 1d | 2014-03-21 | 2014-03-24 | 7 | -84.25d | 0d |  |  | OPERE EDILI | 8h |
| 9 | 1.2.3 | OPERE DI RIPRISTINO STRADA | 1d | 2014-03-24 | 2014-03-25 | 8 | -84.25d | 0d |  | 2013-12-03 | OPERE EDILI | 8h |
| 10 | 1.3 | **OPERE EDILI VIA S.AMBROGIO** | 11d | 2014-03-25 | 2014-04-08 |  | 104.62d |  |  |  |  | 88h |
| 11 | 1.3.1 | OPERE DI CANALIZZAZIONE | 7d | 2014-03-25 | 2014-04-02 | 9 | 104.62d | 0d |  |  | OPERE EDILI | 56h |
| 12 | 1.3.2 | GETTI DI FONDAZIONE | 2d | 2014-04-02 | 2014-04-04 | 11 | 104.62d | 0d |  |  | OPERE EDILI | 16h |
| 13 | 1.3.3 | OPERE DI RIPRISTINO STRADA | 2d | 2014-04-04 | 2014-04-08 | 12 | 104.62d | 0d |  |  | OPERE EDILI | 16h |
| 14 | 1.4 | **OPERE EDILI VIA RAFFAELLO SANZIO** | 8d | 2014-04-08 | 2014-04-18 |  | 104.62d |  |  |  |  | 64h |
| 15 | 1.4.1 | OPERE DI CANALIZZAZIONE | 5d | 2014-04-08 | 2014-04-15 | 13 | 104.62d | 0d |  |  | OPERE EDILI | 40h |
| 16 | 1.4.2 | GETTI DI FONDAZIONE | 2d | 2014-04-15 | 2014-04-17 | 15 | 104.62d | 0d |  |  | OPERE EDILI | 16h |
| 17 | 1.4.3 | OPERE DI RIPRISTINO STRADA | 1d | 2014-04-17 | 2014-04-18 | 16 | 104.62d | 0d |  |  | OPERE EDILI | 8h |
| 18 | 1.5 | **OPERE EDILI VIAS.VINCENZO** | 6d | 2014-04-18 | 2014-04-25 |  | 104.62d | 0d |  |  |  | 48h |
| 19 | 1.5.1 | OPERE DI CANALIZZAZIONE | 4d | 2014-04-18 | 2014-04-23 | 17 | 104.62d | 0d |  |  | OPERE EDILI | 32h |
| 20 | 1.5.2 | GETTI DI FONDAZIONE | 1d | 2014-04-23 | 2014-04-24 | 19 | 104.62d | 0d |  |  | OPERE EDILI | 8h |
| 21 | 1.5.3 | OPERE DI RIPRISTINO STRADA | 1d | 2014-04-24 | 2014-04-25 | 20 | 104.62d | 0d |  |  | OPERE EDILI | 8h |
| 22 | 1.6 | **OPERE EDILI VIA S.ROCCO** | 6d | 2014-04-25 | 2014-05-05 |  | 104.62d |  |  |  |  | 48h |
| 23 | 1.6.1 | OPERE DI CANALIZZAZIONE | 4d | 2014-04-25 | 2014-05-01 | 21 | 104.62d | 0d |  |  | OPERE EDILI | 32h |
| 24 | 1.6.2 | GETTI DI FONDAZIONE | 1d | 2014-05-01 | 2014-05-02 | 23 | 104.62d | 0d |  |  | OPERE EDILI | 8h |
| 25 | 1.6.3 | OPERE DI RIPRISTINO STRADA | 1d | 2014-05-02 | 2014-05-05 | 24 | 104.62d | 0d |  |  | OPERE EDILI | 8h |

| ID | WBS | Task | Type | Duration | Start | Finish | Predecessors | Total slack | Free slack | Resources | Work |
| --- | --- | --- | --- | --- | --- | --- | --- | --- | --- | --- | --- |
| 26 | 1.7 | **OPERE EDILI VIA MARCONI** |  | 11d | 2014-05-05 | 2014-05-19 |  | 104.62d |  |  | 88h |
| 27 | 1.7.1 | OPERE DI CANALIZZAZIONE |  | 7d | 2014-05-05 | 2014-05-14 | 25 | 104.62d | 0d | OPERE EDILI | 56h |
| 28 | 1.7.2 | GETTI DI FONDAZIONE |  | 2d | 2014-05-14 | 2014-05-15 | 27 | 104.62d | 0d | OPERE EDILI | 16h |
| 29 | 1.7.3 | OPERE DI RIPRISTINO STRADA |  | 2d | 2014-05-15 | 2014-05-19 | 28 | 104.62d | 0d | OPERE EDILI | 16h |
| 30 | 1.8 | **OPERE EDILI VIA TAGLIAMENTO** |  | 2d | 2014-05-19 | 2014-05-21 |  | 104.62d |  |  | 16h |
| 31 | 1.8.1 | OPERE DI CANALIZZAZIONE |  | 1d | 2014-05-19 | 2014-05-20 | 29 | 104.62d | 0d | OPERE EDILI | 8h |
| 32 | 1.8.2 | GETTI DI FONDAZIONE |  | 0.5d | 2014-05-20 | 2014-05-21 | 31 | 104.62d | 0d | OPERE EDILI | 4h |
| 33 | 1.8.3 | OPERE DI RIPRISTINO STRADA |  | 0.5d | 2014-05-21 | 2014-05-21 | 32 | 104.62d | 0d | OPERE EDILI | 4h |
| 34 | 1.9 | **OPERE EDILI VIA ISONZO** |  | 3d | 2014-05-21 | 2014-05-26 |  | 104.62d |  |  | 24h |
| 35 | 1.9.1 | OPERE DI CANALIZZAZIONE |  | 2d | 2014-05-21 | 2014-05-23 | 33 | 104.62d | 0d | OPERE EDILI | 16h |
| 36 | 1.9.2 | GETTI DI FONDAZIONE |  | 0.5d | 2014-05-23 | 2014-05-26 | 35 | 104.62d | 0d | OPERE EDILI | 4h |
| 37 | 1.9.3 | OPERE DI RIPRISTINO STRADA |  | 0.5d | 2014-05-26 | 2014-05-26 | 36 | 104.62d | 0d | OPERE EDILI | 4h |
| 38 | 1.10 | **OPERE EDILI VIA LUNGA** |  | 3d | 2014-05-26 | 2014-05-29 |  | 104.62d |  |  | 24h |
| 39 | 1.10.1 | OPERE DI CANALIZZAZIONE |  | 2d | 2014-05-26 | 2014-05-28 | 37 | 104.62d | 0d | OPERE EDILI | 16h |
| 40 | 1.10.2 | GETTI DI FONDAZIONE |  | 0.5d | 2014-05-28 | 2014-05-28 | 39 | 104.62d | 0d | OPERE EDILI | 4h |
| 41 | 1.10.3 | OPERE DI RIPRISTINO STRADA |  | 0.5d | 2014-05-28 | 2014-05-29 | 40 | 104.62d | 0d | OPERE EDILI | 4h |
| 42 | 1.11 | **OPERE EDILI VIA MONTE ROSA** |  | 5d | 2014-05-29 | 2014-06-05 |  | 104.62d |  |  | 40h |
| 43 | 1.11.1 | OPERE DI CANALIZZAZIONE |  | 3d | 2014-05-29 | 2014-06-03 | 41 | 104.62d | 0d | OPERE EDILI | 24h |
| 44 | 1.11.2 | GETTI DI FONDAZIONE |  | 1d | 2014-06-03 | 2014-06-04 | 43 | 104.62d | 0d | OPERE EDILI | 8h |
| 45 | 1.11.3 | OPERE DI RIPRISTINO STRADA |  | 1d | 2014-06-04 | 2014-06-05 | 44 | 104.62d | 0d | OPERE EDILI | 8h |
| 46 | 1.12 | **OPERE EDILI VIA MONTE BIANCO** |  | 2d | 2014-06-05 | 2014-06-06 |  | 104.62d |  |  | 16h |
| 47 | 1.12.1 | OPERE DI CANALIZZAZIONE |  | 1d | 2014-06-05 | 2014-06-05 | 45 | 104.62d | 0d | OPERE EDILI | 8h |
| 48 | 1.12.2 | GETTI DI FONDAZIONE | milestone | 0d | 2014-06-05 | 2014-06-05 | 47 | 104.62d | 0d | OPERE EDILI |  |
| 49 | 1.12.3 | OPERE DI RIPRISTINO STRADA |  | 1d | 2014-06-06 | 2014-06-06 | 48 | 104.62d | 0d | OPERE EDILI | 8h |

| ID | WBS | Task | Type | Duration | Start | Finish | Predecessors | Total slack | Free slack | Constraint | Resources | Work |
| --- | --- | --- | --- | --- | --- | --- | --- | --- | --- | --- | --- | --- |
| 50 | 1.13 | **OPERE EDILI VIA ARNABOLDI** |  | 10d | 2014-06-06 | 2014-06-20 | 49 | 104.62d |  |  |  | 80h |
| 51 | 1.13.1 | OPERE DI CANALIZZAZIONE |  | 6d | 2014-06-06 | 2014-06-16 | 49 | 104.62d | 0d |  | OPERE EDILI | 48h |
| 52 | 1.13.2 | GETTI DI FONDAZIONE |  | 2d | 2014-06-16 | 2014-06-18 | 51 | 104.62d | 0d |  | OPERE EDILI | 16h |
| 53 | 1.13.3 | OPERE DI RIPRISTINO STRADA |  | 2d | 2014-06-18 | 2014-06-20 | 52 | 104.62d | 0d |  | OPERE EDILI | 16h |
| 54 | 2 | **OPERE ELETTRCHE INTERVENTI OBBLIGATORI** |  | 42d | 2014-04-25 | 2014-06-20 | 18, 14 | 104.62d |  |  |  | 300h |
| 55 | 2.1 | **OPERE ELETTRCIHE VIA TRENTO** |  | 3d | 2014-04-25 | 2014-04-30 |  | 109.12d |  |  |  | 24h |
| 56 | 2.1.1 | POSA DI NUOVI COMPLESSI ILLUMINANTI A PALO |  | 1d | 2014-04-25 | 2014-04-28 | 41 | 109.12d | 0d | start no earlier than 2014-03-24 | OPERE ELETTRICHE 1 | 8h |
| 57 | 2.1.2 | POSA CAVI ED ESECUZIONE DI TUTTI I COLLEGAMENTI NECESSARI |  | 1d | 2014-04-28 | 2014-04-29 | 56 | 109.12d | 0d |  | OPERE ELETTRICHE 1 | 8h |
| 58 | 2.1.3 | RECUPERO E DISMISSIONE VECCHIO IMPIANTO E ATTIVAZIONE NUOVO |  | 1d | 2014-04-29 | 2014-04-30 | 57 | 109.12d | 0d |  | OPERE ELETTRICHE 1 | 8h |
| 59 | 2.2 | **OPERE ELETTRICHE VIA GIOVANNI XXVIII** |  | 3d | 2014-04-30 | 2014-05-05 |  | 109.12d |  |  |  | 24h |
| 60 | 2.2.1 | POSA DI NUOVI COMPLESSI ILLUMINANTI A PALO |  | 1d | 2014-04-30 | 2014-05-01 | 58 | 109.12d | 0d |  | OPERE ELETTRICHE 1 | 8h |
| 61 | 2.2.2 | POSA CAVI ED ESECUZIONE DI TUTTI I COLLEGAMENTI NECESSARI |  | 1d | 2014-05-01 | 2014-05-02 | 60 | 109.12d | 0d |  | OPERE ELETTRICHE 1 | 8h |
| 62 | 2.2.3 | RECUPERO E DISMISSIONE VECCHIO IMPIANTO E ATTIVAZIONE NUOVO |  | 1d | 2014-05-02 | 2014-05-05 | 61 | 109.12d | 0d |  | OPERE ELETTRICHE 1 | 8h |
| 63 | 2.3 | **OPERE ELETTRCIHE VIA S.AMBROGIO** |  | 5d | 2014-05-05 | 2014-05-12 |  | 109.12d |  |  |  | 40h |
| 64 | 2.3.1 | POSA DI NUOVI COMPLESSI ILLUMINANTI A PALO |  | 2d | 2014-05-05 | 2014-05-07 | 62 | 109.12d | 0d |  | OPERE ELETTRICHE 1 | 16h |
| 65 | 2.3.2 | POSA CAVI ED ESECUZIONE DI TUTTI I COLLEGAMENTI NECESSARI |  | 2d | 2014-05-07 | 2014-05-09 | 64 | 109.12d | 0d |  | OPERE ELETTRICHE 1 | 16h |
| 66 | 2.3.3 | RECUPERO E DISMISSIONE VECCHIO IMPIANTO E ATTIVAZIONE NUOVO |  | 1d | 2014-05-09 | 2014-05-12 | 65 | 109.12d | 0d |  | OPERE ELETTRICHE 1 | 8h |
| 67 | 2.4 | **OPERE ELETTRCIHE VIA RAFFAELLO SANZIO** |  | 2d | 2014-05-12 | 2014-05-14 |  | 109.12d |  |  |  | 16h |
| 68 | 2.4.1 | POSA DI NUOVI COMPLESSI ILLUMINANTI A PALO |  | 1d | 2014-05-12 | 2014-05-13 | 66 | 109.12d | 0d |  | OPERE ELETTRICHE 1 | 8h |
| 69 | 2.4.2 | POSA CAVI ED ESECUZIONE DI TUTTI I COLLEGAMENTI NECESSARI |  | 1d | 2014-05-13 | 2014-05-14 | 68 | 109.12d | 0d |  | OPERE ELETTRICHE 1 | 8h |
| 70 | 2.4.3 | RECUPERO E DISMISSIONE VECCHIO IMPIANTO E ATTIVAZIONE NUOVO | milestone | 0d | 2014-05-14 | 2014-05-14 | 69 | 109.12d | 0d |  | OPERE ELETTRICHE 1 |  |
| 71 | 2.5 | **OPERE ELETTRCIHE VIA S.VINCENZO** |  | 3d | 2014-05-14 | 2014-05-16 |  | 109.12d |  |  |  | 24h |
| 72 | 2.5.1 | POSA DI NUOVI COMPLESSI ILLUMINANTI A PALO |  | 1d | 2014-05-14 | 2014-05-14 | 70 | 109.12d | 0d |  | OPERE ELETTRICHE 1 | 8h |
| 73 | 2.5.2 | POSA CAVI ED ESECUZIONE DI TUTTI I COLLEGAMENTI NECESSARI |  | 1d | 2014-05-15 | 2014-05-15 | 72 | 109.12d | 0d |  | OPERE ELETTRICHE 1 | 8h |
| 74 | 2.5.3 | RECUPERO E DISMISSIONE VECCHIO IMPIANTO E ATTIVAZIONE NUOVO |  | 1d | 2014-05-15 | 2014-05-16 | 73 | 109.12d | 0d |  | OPERE ELETTRICHE 1 | 8h |

| ID | WBS | Task | Type | Duration | Start | Finish | Predecessors | Total slack | Free slack | Constraint | Resources | Work |
| --- | --- | --- | --- | --- | --- | --- | --- | --- | --- | --- | --- | --- |
| 75 | 2.6 | **OPERE ELETTRCIHE VIA S.ROCCO** |  | 2d | 2014-05-16 | 2014-05-20 |  | 109.12d |  |  |  | 16h |
| 76 | 2.6.1 | POSA DI NUOVI COMPLESSI ILLUMINANTI A PALO |  | 1d | 2014-05-16 | 2014-05-19 | 74 | 109.12d | 0d |  | OPERE ELETTRICHE 1 | 8h |
| 77 | 2.6.2 | POSA CAVI ED ESECUZIONE DI TUTTI I COLLEGAMENTI NECESSARI |  | 1d | 2014-05-19 | 2014-05-20 | 76 | 109.12d | 0d |  | OPERE ELETTRICHE 1 | 8h |
| 78 | 2.6.3 | RECUPERO E DISMISSIONE VECCHIO IMPIANTO E ATTIVAZIONE NUOVO | milestone | 0d | 2014-05-20 | 2014-05-20 | 77 | 109.12d | 0d |  | OPERE ELETTRICHE 1 |  |
| 79 | 2.7 | **OPERE ELETTRCIHE VIA MARCONI** |  | 4.5d | 2014-05-20 | 2014-05-26 |  | 109.12d |  |  |  | 36h |
| 80 | 2.7.1 | POSA DI NUOVI COMPLESSI ILLUMINANTI A PALO |  | 2.5d | 2014-05-20 | 2014-05-23 | 78 | 109.12d | 0d | start no earlier than 2014-05-19 | OPERE ELETTRICHE 1 | 20h |
| 81 | 2.7.2 | POSA CAVI ED ESECUZIONE DI TUTTI I COLLEGAMENTI NECESSARI |  | 1d | 2014-05-23 | 2014-05-26 | 80 | 109.12d | 0d | start no earlier than 2014-05-02 | OPERE ELETTRICHE 1 | 8h |
| 82 | 2.7.3 | RECUPERO E DISMISSIONE VECCHIO IMPIANTO E ATTIVAZIONE NUOVO |  | 1d | 2014-05-26 | 2014-05-26 | 81 | 109.12d | 0d |  | OPERE ELETTRICHE 1 | 8h |
| 83 | 2.8 | **OPERE ELETTRCIHE VIA TAGLIAMENTO** |  | 2d | 2014-05-27 | 2014-05-28 |  | 109.12d |  |  |  | 16h |
| 84 | 2.8.1 | POSA DI NUOVI COMPLESSI ILLUMINANTI A PALO |  | 1d | 2014-05-27 | 2014-05-27 | 82 | 109.12d | 0d |  | OPERE ELETTRICHE 1 | 8h |
| 85 | 2.8.2 | POSA CAVI ED ESECUZIONE DI TUTTI I COLLEGAMENTI NECESSARI |  | 1d | 2014-05-27 | 2014-05-28 | 84 | 109.12d | 0d |  | OPERE ELETTRICHE 1 | 8h |
| 86 | 2.8.3 | RECUPERO E DISMISSIONE VECCHIO IMPIANTO E ATTIVAZIONE NUOVO | milestone | 0d | 2014-05-28 | 2014-05-28 | 85 | 109.12d | 0d |  | OPERE ELETTRICHE 1 |  |
| 87 | 2.9 | **OPERE ELETTRCIHE VIA ISONZO** |  | 2d | 2014-05-28 | 2014-05-30 |  | 109.12d |  |  |  | 16h |
| 88 | 2.9.1 | POSA DI NUOVI COMPLESSI ILLUMINANTI A PALO |  | 1d | 2014-05-28 | 2014-05-29 | 86 | 109.12d | 0d |  | OPERE ELETTRICHE 1 | 8h |
| 89 | 2.9.2 | POSA CAVI ED ESECUZIONE DI TUTTI I COLLEGAMENTI NECESSARI |  | 1d | 2014-05-29 | 2014-05-30 | 88 | 109.12d | 0d |  | OPERE ELETTRICHE 1 | 8h |
| 90 | 2.9.3 | RECUPERO E DISMISSIONE VECCHIO IMPIANTO E ATTIVAZIONE NUOVO | milestone | 0d | 2014-05-30 | 2014-05-30 | 89 | 109.12d | 0d |  | OPERE ELETTRICHE 1 |  |
| 91 | 2.10 | **OPERE ELETTRCIHE VIA LUNGA** |  | 3d | 2014-05-30 | 2014-06-04 |  | 109.12d |  |  |  | 24h |
| 92 | 2.10.1 | POSA DI NUOVI COMPLESSI ILLUMINANTI A PALO |  | 1d | 2014-05-30 | 2014-06-02 | 90 | 109.12d | 0d |  | OPERE ELETTRICHE 1 | 8h |
| 93 | 2.10.2 | POSA CAVI ED ESECUZIONE DI TUTTI I COLLEGAMENTI NECESSARI |  | 1d | 2014-06-02 | 2014-06-03 | 92 | 109.12d | 0d |  | OPERE ELETTRICHE 1 | 8h |
| 94 | 2.10.3 | RECUPERO E DISMISSIONE VECCHIO IMPIANTO E ATTIVAZIONE NUOVO |  | 1d | 2014-06-03 | 2014-06-04 | 93 | 109.12d | 0d |  | OPERE ELETTRICHE 1 | 8h |
| 95 | 2.11 | **OPERE ELETTRCIHE VIA MONTE ROSA** |  | 3d | 2014-06-04 | 2014-06-09 |  | 109.12d |  |  |  | 24h |
| 96 | 2.11.1 | POSA DI NUOVI COMPLESSI ILLUMINANTI A PALO |  | 2d | 2014-06-04 | 2014-06-06 | 94 | 109.12d | 0d |  | OPERE ELETTRICHE 1 | 16h |
| 97 | 2.11.2 | POSA CAVI ED ESECUZIONE DI TUTTI I COLLEGAMENTI NECESSARI |  | 1d | 2014-06-06 | 2014-06-09 | 96 | 109.12d | 0d |  | OPERE ELETTRICHE 1 | 8h |
| 98 | 2.11.3 | RECUPERO E DISMISSIONE VECCHIO IMPIANTO E ATTIVAZIONE NUOVO | milestone | 0d | 2014-06-09 | 2014-06-09 | 97 | 109.12d | 0d |  | OPERE ELETTRICHE 1 |  |

| ID | WBS | Task | Type | Duration | Start | Finish | Predecessors | Total slack | Free slack | Constraint | Resources | Work |
| --- | --- | --- | --- | --- | --- | --- | --- | --- | --- | --- | --- | --- |
| 99 | 2.12 | **OPERE ELETTRCIHE VIA MONTE BIANCO** |  | 2d | 2014-06-09 | 2014-06-11 |  | 109.12d |  |  |  | 16h |
| 100 | 2.12.1 | POSA DI NUOVI COMPLESSI ILLUMINANTI A PALO |  | 1d | 2014-06-09 | 2014-06-10 | 98 | 109.12d | 0d |  | OPERE ELETTRICHE 1 | 8h |
| 101 | 2.12.2 | POSA CAVI ED ESECUZIONE DI TUTTI I COLLEGAMENTI NECESSARI |  | 1d | 2014-06-10 | 2014-06-11 | 100 | 109.12d | 0d |  | OPERE ELETTRICHE 1 | 8h |
| 102 | 2.12.3 | RECUPERO E DISMISSIONE VECCHIO IMPIANTO E ATTIVAZIONE NUOVO | milestone | 0d | 2014-06-11 | 2014-06-11 | 101 | 109.12d | 0d |  | OPERE ELETTRICHE 1 |  |
| 103 | 2.13 | **OPERE ELETTRCIHE VIA ARNABOLDI** |  | 7.5d | 2014-06-11 | 2014-06-20 |  | 104.62d |  |  |  | 24h |
| 104 | 2.13.1 | POSA DI NUOVI COMPLESSI ILLUMINANTI A PALO |  | 1d | 2014-06-11 | 2014-06-12 | 102 | 109.12d | 0d |  | OPERE ELETTRICHE 1 | 8h |
| 105 | 2.13.2 | POSA CAVI ED ESECUZIONE DI TUTTI I COLLEGAMENTI NECESSARI |  | 1d | 2014-06-12 | 2014-06-13 | 104 | 109.12d | 4.5d |  | OPERE ELETTRICHE 1 | 8h |
| 106 | 2.13.3 | RECUPERO E DISMISSIONE VECCHIO IMPIANTO E ATTIVAZIONE NUOVO |  | 1d | 2014-06-19 | 2014-06-20 | 105, 53FF | 104.62d |  |  | OPERE ELETTRICHE 1 | 8h |
| 107 | 3 | **INTERVENTI DI ADEGUAMENTO NORMATIVO** |  | 169.19d | 2014-03-03 | 2014-11-10 |  | 19.75d |  |  |  | 4560h |
| 108 | 3.1 | OPERE DI CANALIZZAZIONE |  | 50d | 2014-06-23 | 2014-09-25 | 53 | 53.94d |  | start no earlier than 2014-06-23 | OPERE EDILI | 400h |
| 109 | 3.2 | GETTI DI FONDAZIONE |  | 50d | 2014-06-23 | 2014-09-25 | 108 | 53.94d |  | start no earlier than 2014-06-23 | OPERE EDILI | 400h |
| 110 | 3.3 | OPERE DI RIPRISTINO STRADA |  | 50d | 2014-06-23 | 2014-09-25 | 109 | 53.94d |  | start no earlier than 2014-06-23 | OPERE EDILI | 400h |
| 111 | 3.4 | POSA DI LINEA IN CAVO INTERRATA |  | 50d | 2014-06-23 | 2014-09-25 | 110 | 53.94d |  | start no earlier than 2014-06-23 | OPERE ELETTRICHE 2 | 400h |
| 112 | 3.5 | ESECUZIONE LINEA AEREA |  | 50d | 2014-06-23 | 2014-09-25 | 111, 120 | 53.94d |  | start no earlier than 2014-06-23 | OPERE ELETTRICHE 2 | 400h |
| 113 | 3.6 | SOSTITUZIONE SOSTEGNI A PALO |  | 120d | 2014-03-03 | 2014-09-04 | 112 | 68.94d |  | start no earlier than 2014-03-03 | OPERE ELETTRICHE 2 | 960h |
| 114 | 3.7 | SOSTITUZIONE DI SOSTEGNI A BRACCIO ESISTENTI |  | 120d | 2014-03-03 | 2014-09-04 | 113 | 68.94d |  | start no earlier than 2014-03-03 | OPERE ELETTRICHE 2 | 960h |
| 115 | 3.8 | SOSTITUZIONE DI QUADRI DI COMANDO |  | 30d | 2014-10-01 | 2014-11-10 | 114 | 19.75d |  | start no earlier than 2014-10-01 | OPERE ELETTRICHE 2 | 240h |
| 116 | 3.9 | RECUPERO E DEMOLIZIONE LINEE AEREE ESISTENTI |  | 50d | 2014-06-23 | 2014-09-25 | 115 | 53.94d |  | start no earlier than 2014-06-23 | OPERE ELETTRICHE 2 | 400h |
| 117 | 4 | **OPERE DI RISPARIO ENERGETICO** |  | 120d | 2014-03-03 | 2014-09-04 |  | 68.94d |  |  |  | 1920h |
| 118 | 4.1 | SOSTITUZIONE DI APPARECCHI DI ILLUMINAZIONE |  | 120d | 2014-03-03 | 2014-09-04 |  | 68.94d |  | start no earlier than 2014-03-03 | OPERE ELETTRICHE 2 | 960h |
| 119 | 4.2 | RICABLAGGIO APPARECCHI DI ILLUMINAZIONE ESISTENTI |  | 60d | 2014-05-02 | 2014-07-21 | 118 | 82.19d |  | start no earlier than 2014-05-02 | OPERE ELETTRICHE 2 | 480h |
| 120 | 4.3 | POSA INTERRUTTORI ASTRONOMICI NEI QUADRI DI COMANDO |  | 60d | 2014-05-02 | 2014-07-21 | 119 | 82.19d |  | start no earlier than 2014-05-02 | OPERE ELETTRICHE 2 | 480h |
| 121 | 5 | **OPERE DI RIQUALIFICAZIONE TECNOLOGICA** |  | 20d | 2014-11-10 | 2014-12-04 |  | 0d |  |  |  | 160h |
| 122 | 5.1 | ISTALLAZIONE SISTEMA DI TELEGESTIONE NEI QUADRI DI COMANDO |  | 20d | 2014-11-10 | 2014-12-04 |  | 0d |  | start no earlier than 2014-11-10 | OPERE ELETTRICHE 2 | 160h |
